# CONSTRUCCION DE DIQUES NATURALIZADOS PARA EL SUBPROYECTO A1

Schedule from Primavera P6, 2024-11-11 to 2025-06-08, data date 2024-11-11, costs in PEN.

## Calendars

- SubProyecto A1 - Diques Naturalizados - Días Hábiles: Mon-Sun 08:00-12:00, 13:00-17:00.
- SubProyecto A1 - Nuevo Chimbote OHLA: Mon-Sun 08:00-12:00, 13:00-17:00.

## Resources

| Resource | Group | Rate |
| --- | --- | --- |
| Camión Volquete 15 m3 | equipment | 287.45 |
| TRANSPORTE DE MATERIAL GRANULAR PARA DISTANCIAS <1KM | labor | 27.35 |
| TRANSPORTE DE MATERIAL GRANULAR PARA DISTANCIAS >1KM | labor | 27.78 |
| Camión Volquete 15 m3 | equipment | 287.95 |
| TRANSPORTE DE MATERIAL EXCEDENTE PARA DISTANCIAS <1KM | labor | 27.47 |
| Camión Volquete 15 m3 | equipment | 287.48 |
| TRANSPORTE DE MATERIAL EXCEDENTE PARA DISTANCIAS >1KM | labor | 27.78 |
| Camión Volquete 15 m3 | equipment | 287.95 |
| Equipos | equipment | 52.26 |
| Herramientas Manuales | equipment | 23.21 |
| ACERO CORRUGADO fy = 4200 kg/cm2 GRADO 60 | material | 6.96 |
| YESO BOLSA 18 kg | material | 19.03 |
| PINTURA ESMALTE SINTETICO TEKNO | material | 38.19 |
| CORDEL | material | 0.4 |
| MO - TRAZO Y REPLANTEO INICIAL | labor | 23.21 |
| SC ELIMINACION DE RESIDUOS SOLIDOS GENERALES MUNICIPALES | material | 35.84 |
| Cargador Sobre Llantas | equipment | 334.76 |
| MO - CORTE PARA CIMENTACIÓN DE DIQUE NATURALIZADO h=30cm | labor | 20.83 |
| Herramientas Manuales | equipment | 20.98 |
| Tractor Oruga | equipment | 388.88 |
| MO - PERFILADO Y COMPACTACION EN ZONA DE CORTE | labor | 21.05 |
| Herramientas Manuales | equipment | 33.52 |
| Rodillo Liso Vibratorio | equipment | 192.5 |
| Motoniveladora | equipment | 366.49 |
| Camion Cisterna | equipment | 241.36 |
| MO - CONFORMACIÓN DE CUERPO DE DIQUE NATURALZADO CON RELLENO COMPACTADO | labor | 20.3 |
| Herramientas Manuales | equipment | 20.18 |
| Camion Cisterna | equipment | 242.95 |
| Rodillo Liso Vibratorio | equipment | 198.25 |
| Motoniveladora | equipment | 364.69 |
| Excavadora Oruga | equipment | 448.05 |
| AFIRMADO | material | 33.58 |
| SC ZARANDEO DE MATERIAL PROPIO Y CARGUIO DE MATERIAL GRANULAR | material | 6.35 |
| MO - EXCAVACIÓN MANUAL PARA INSTALACIÓN DE BORDILLOS Y CIMENTACIONES | labor | 20.16 |
| Herramientas Manuales | equipment | 20.03 |
| MO - EXCAVACIÓN PARA MEJORAMIENTO DE SUELO CON TIERRA VEGETAL | labor | 20.06 |
| Herramientas Manuales | equipment | 6.12 |
| Excavadora Oruga | equipment | 423.64 |
| MO - PISO TIERRA APISONADA (h=0.35cm) | labor | 20.37 |
| Herramientas Manuales | equipment | 20.16 |
| Rodillo Chupetero | equipment | 41.13 |
| AGUA | material | 17.5 |
| MANTA DE ASFALTO | material | 28.44 |
| MO - RECUBRIMIENTO DE PIEDRA DEL LUGAR e=0.05cm | labor | 25.66 |
| Equipos | equipment | 14.1 |
| Herramientas Manuales | equipment | 24.57 |
| SELECCIÓN Y ACOPIO DE PIEDRA | material | 15.78 |
| MORTERO | material | 12.37 |
| MO - BORDILLOS DE PIEDRA DEL LUGAR | labor | 20.27 |
| Herramientas Manuales | equipment | 20.25 |
| SELECCIÓN Y ACOPIO DE PIEDRA | material | 15.78 |
| MORTERO | material | 12.66 |
| SC EXCAVACION DE CIMENTACION MANUAL | material | 74.67 |
| SC ELIMINACION DE MATERIAL EXCEDENTE | material | 30.21 |
| SC CONCRETO PARA CIMENTACION MEZCLA 1:10 + 30% PG | material | 302.8 |
| SC ENCOFRADO Y DESENCOFRADO | material | 81.09 |
| SC SUMINISTRO E INSTALACION DE TACHOS DE MADERA | material | 335.76 |
| SC ACERO ESTRUCTURAL fy=4200 kg/cm2 | material | 6.99 |
| SC COLOCACION DE CONCRETO 175 KG/CM2 | material | 319.2 |
| SC EXCAVACION DE CIMENTACION MANUAL | material | 69.94 |
| SC ELIMINACION DE MATERIAL EXCEDENTE | material | 32.46 |
| SC CONCRETO PARA CIMENTACION MEZCLA 1:10 + 30% PG | material | 351.67 |
| SC COLOCACION DE CONCRETO 175 KG/CM2 | material | 337.06 |
| SC ACERO ESTRUCTURAL fy=4200 kg/cm2 | material | 6.98 |
| SC ENCOFRADO Y DESENCOFRADO | material | 82.31 |
| MO - POSTES DE ILUMINACION, INCLUYE LUMINARIA Y CIMENTACION | labor | 22.69 |
| Herramientas Manuales | equipment | 22.29 |
| CLAVOS PARA MADERA CON CABEZA 1 1/2" | material | 6.6 |
| POSTE DE EUCALIPTO D=6"X4M | material | 21.42 |
| SC EXCAVACION DE CIMENTACION MANUAL | material | 34.2 |
| SC CONCRETO PARA CIMENTACION MEZCLA 1:10 + 30% PG | material | 309.8 |
| SC ACERO ESTRUCTURAL fy=4200 kg/cm2 | material | 6.99 |
| SC COLOCACION DE BREA LIQUIDA | material | 44.7 |
| SC SUMINISTRO E INSTALACION DE LUMINARIA SOLAR | material | 2985 |
| SC ENCOFRADO Y DESENCOFRADO | material | 80.29 |
| SC SUMINISTRO E INSTALACION DE PANEL INFORMATIVO | material | 52.67 |
| SC ACABADO DE PINTURA BARNIZ POLIURETANO (2 MANOS) | material | 161.23 |
| MO - SEÑALETICA INFORMATIVA | labor | 23.83 |
| Equipos | equipment | 29.78 |
| Herramientas Manuales | equipment | 19.08 |
| ABRAZADERA DE 1" | material | 6.12 |
| PINTURA ANTICORROSIVA | material | 17.25 |
| DISOLVENTE XILOL | material | 18.5 |
| SOLDADURA AWS E6011 | material | 10 |
| LAMINA REFLECTIVA ALTA INTENSIDAD | material | 48.5 |
| PLATINAS DE ACERO INOXIDABLE E=1/8" | material | 89.8 |
| MO - BOLARDOS DE PIEDRA | labor | 20.12 |
| SELECCION Y ACOPIO DE PIEDRA | material | 15.78 |
| SC TRASLADO DE BOLARDOS A ZONA DE ACOPIO | material | 19.69 |
| MO - TRANQUERA | labor | 23.83 |
| CLAVOS PARA MADERA CON CABEZA 1 1/2" | material | 6.93 |
| LISTON DE EUCALIPTO D=2"X4M | material | 23.5 |
| LISTON DE EUCALIPTO D=3"X4M | material | 25.9 |
| LISTON DE EUCALIPTO D=4"X4M | material | 28.78 |
| BISAGRAS DE FIERRO | material | 29.4 |
| SC ACERO ESTRUCTURAL fy=4200 kg/cm2 | material | 6.99 |
| SC COLOCACION DE BREA LIQUIDA | material | 44.7 |
| SC CONCRETO CICLOPEO 175 KG/CM2 + 30% PG | material | 362.78 |
| SC ACABADO DE PINTURA BARNIZ POLIURETANO (2 MANOS) | material | 161.23 |
| MO - MEJORAMIENTO DE SUELO CON TIERRA DE CHACRA (incluye despedregado y rastrillado) | labor | 19.64 |
| Herramientas Manuales | equipment | 19.68 |
| TIERRA DE CHACRA | material | 45.92 |
| SC TRANSPORTE DE TIERRA DE CHACRA | material | 29.1 |
| Equipos | equipment | 52.23 |
| Herramientas Manuales | equipment | 23.06 |
| ACERO CORRUGADO fy = 4200 kg/cm2 GRADO 60 | material | 6.96 |
| YESO BOLSA 18 kg | material | 19.05 |
| PINTURA ESMALTE SINTETICO TEKNO | material | 38.43 |
| CORDEL | material | 0.4 |
| MO - TRAZO Y REPLANTEO INICIAL | labor | 23.21 |
| Cargador Sobre Llantas | equipment | 334.94 |
| SC ELIMINACION DE RESIDUOS SOLIDOS GENERALES MUNICIPALES | material | 35.84 |
| MO - CORTE PARA CIMENTACIÓN DE DIQUE NATURALIZADO h=30cm | labor | 20.85 |
| Herramientas Manuales | equipment | 21.15 |
| Tractor Oruga | equipment | 388.81 |
| MO - PERFILADO Y COMPACTACION EN ZONA DE CORTE | labor | 20.98 |
| Herramientas Manuales | equipment | 34.59 |
| Rodillo Liso Vibratorio | equipment | 192.23 |
| Motoniveladora | equipment | 365.98 |
| Camion Cisterna | equipment | 242.14 |
| MO - CONFORMACIÓN DE CUERPO DE DIQUE NATURALZADO CON RELLENO COMPACTADO | labor | 20.27 |
| Herramientas Manuales | equipment | 19.22 |
| Rodillo Liso Vibratorio | equipment | 198.36 |
| Excavadora Oruga | equipment | 425.71 |
| Motoniveladora | equipment | 363.02 |
| Camion Cisterna | equipment | 241.84 |
| AFIRMADO | material | 33.58 |
| SC ZARANDEO DE MATERIAL PROPIO Y CARGUIO DE MATERIAL GRANULAR | material | 6.35 |
| MO - EXCAVACIÓN MANUAL PARA INSTALACIÓN DE BORDILLOS Y CIMENTACIONES | labor | 20.11 |
| Herramientas Manuales | equipment | 19.36 |
| MO - PISO TIERRA APISONADA (h=0.35cm) | labor | 20.37 |
| Herramientas Manuales | equipment | 20.04 |
| Rodillo Chupetero | equipment | 41.12 |
| AGUA | material | 17.49 |
| MANTA DE ASFALTO | material | 28.44 |
| MO - RECUBRIMIENTO DE PIEDRA DEL LUGAR e=0.05cm | labor | 25.72 |
| Equipos | equipment | 7.22 |
| Herramientas Manuales | equipment | 25.18 |
| SELECCIÓN Y ACOPIO DE PIEDRA | material | 15.51 |
| MORTERO | material | 12.28 |
| MO - BORDILLOS DE PIEDRA DEL LUGAR | labor | 20.27 |
| Herramientas Manuales | equipment | 20.27 |
| SELECCIÓN Y ACOPIO DE PIEDRA | material | 15.78 |
| MORTERO | material | 12.66 |
| SC EXCAVACION DE CIMENTACION MANUAL | material | 62.88 |
| SC ELIMINACION DE MATERIAL EXCEDENTE | material | 12.72 |
| SC CONCRETO PARA CIMENTACION MEZCLA 1:10 + 30% PG | material | 191.24 |
| SC COLOCACION DE CONCRETO 175 KG/CM2 | material | 67.2 |
| SC ACERO ESTRUCTURAL fy=4200 kg/cm2 | material | 6.97 |
| SC SUMINISTRO E INSTALACION DE TACHOS DE MADERA | material | 335.76 |
| SC ENCOFRADO Y DESENCOFRADO | material | 81.94 |
| SC EXCAVACION DE CIMENTACION MANUAL | material | 68.71 |
| SC ELIMINACION DE MATERIAL EXCEDENTE | material | 31.89 |
| SC CONCRETO PARA CIMENTACION MEZCLA 1:10 + 30% PG | material | 345.5 |
| SC COLOCACION DE CONCRETO 175 KG/CM2 | material | 347.7 |
| SC ACERO ESTRUCTURAL fy=4200 kg/cm2 | material | 6.98 |
| SC ENCOFRADO Y DESENCOFRADO | material | 82.4 |
| MO - POSTES DE ILUMINACION, INCLUYE LUMINARIA Y CIMENTACION | labor | 22.02 |
| Herramientas Manuales | equipment | 17.6 |
| CLAVOS PARA MADERA CON CABEZA 1 1/2" | material | 6.95 |
| POSTE DE EUCALIPTO D=6"X4M | material | 21.42 |
| SC EXCAVACION DE CIMENTACION MANUAL | material | 9 |
| SC CONCRETO PARA CIMENTACION MEZCLA 1:10 + 30% PG | material | 326.1 |
| SC ACERO ESTRUCTURAL fy=4200 kg/cm2 | material | 6.99 |
| SC COLOCACION DE BREA LIQUIDA | material | 44.7 |
| SC SUMINISTRO E INSTALACION DE LUMINARIA SOLAR | material | 2985 |
| SC ENCOFRADO Y DESENCOFRADO | material | 63.38 |
| SC SUMINISTRO E INSTALACION DE PANEL INFORMATIVO | material | 52.67 |
| SC ACABADO DE PINTURA BARNIZ POLIURETANO (2 MANOS) | material | 161.23 |
| MO - SEÑALETICA INFORMATIVA | labor | 22.88 |
| Equipos | equipment | 28.59 |
| Herramientas Manuales | equipment | 13.74 |
| ABRAZADERA DE 1" | material | 6.12 |
| PINTURA ANTICORROSIVA | material | 4.14 |
| DISOLVENTE XILOL | material | 4.44 |
| SOLDADURA AWS E6011 | material | 4.8 |
| LAMINA REFLECTIVA ALTA INTENSIDAD | material | 34.92 |
| PLATINAS DE ACERO INOXIDABLE E=1/8" | material | 89.8 |
| MO - BOLARDOS DE PIEDRA | labor | 20.16 |
| SELECCION Y ACOPIO DE PIEDRA | material | 15.78 |
| SC TRASLADO DE BOLARDOS A ZONA DE ACOPIO | material | 19.69 |
| MO - TRANQUERA | labor | 23.83 |
| CLAVOS PARA MADERA CON CABEZA 1 1/2" | material | 6.93 |
| LISTON DE EUCALIPTO D=2"X4M | material | 23.5 |
| LISTON DE EUCALIPTO D=3"X4M | material | 25.9 |
| LISTON DE EUCALIPTO D=4"X4M | material | 28.78 |
| BISAGRAS DE FIERRO | material | 29.4 |
| SC ACERO ESTRUCTURAL fy=4200 kg/cm2 | material | 6.99 |
| SC COLOCACION DE BREA LIQUIDA | material | 44.7 |
| SC CONCRETO CICLOPEO 175 KG/CM2 + 30% PG | material | 362.78 |
| SC ACABADO DE PINTURA BARNIZ POLIURETANO (2 MANOS) | material | 161.23 |
| MO - MEJORAMIENTO DE SUELO CON TIERRA DE CHACRA (incluye despedregado y rastrillado) | labor | 19.64 |
| Herramientas Manuales | equipment | 19.65 |
| TIERRA DE CHACRA | material | 45.92 |
| SC TRANSPORTE DE TIERRA DE CHACRA | material | 29.1 |

## Schedule

| ID | WBS | Activity | Type | Duration | Start | Finish | Predecessors | Total float | Free float | Calendar | Resources | Cost |
| --- | --- | --- | --- | --- | --- | --- | --- | --- | --- | --- | --- | --- |
|  | 000 | **GENERALES** |  |  | 2024-11-11 | 2025-06-08 |  |  |  |  |  |  |
|  | H | **HITOS** |  |  | 2024-11-11 | 2025-06-08 |  |  |  |  |  |  |
| A1000 |  | HITO DE INICIO | milestone | 0d | 2024-11-11 | 2024-11-11 |  | 0d |  |  |  |  |
| A1010 |  | HITO DE FIN | milestone | 0d | 2025-06-08 | 2025-06-08 | A1240 FF, A1420 FF | 0d |  |  |  |  |
|  | C | **OBRAS PRELIMINARES** |  |  | 2024-11-11 | 2024-11-20 |  |  |  |  |  |  |
| A1450 |  | INSTALACIONES PROVISIONALES |  | 10d | 2024-11-11 | 2024-11-20 | A1000 SS | 0d |  | SubProyecto A1 - Nuevo Chimbote OHLA |  |  |
|  | 890 | **ARQUITECTURA, URBANISMO Y PAISAJISMO** |  |  | 2024-11-11 | 2025-06-08 |  |  |  |  |  |  |
|  | C | **CONSTRUCCIÓN** |  |  | 2024-11-11 | 2025-06-08 |  |  |  |  |  |  |
|  | 1 | **TRANSPORTE DE MATERIAL** |  |  | 2024-11-21 | 2025-05-15 |  |  |  |  |  |  |
| A1040 |  | TRANSPORTE DE MATERIAL GRANULAR PARA DISTANCIAS <1KM |  | 176d | 2024-11-21 | 2025-05-15 | A1100 SS, A1290 SS, A1450 | 24d |  |  | Camión Volquete 15 m3 [690 h]; TRANSPORTE DE MATERIAL GRANULAR PARA DISTANCIAS <1KM [154 h] | 202,554.42 |
| A1050 |  | TRANSPORTE DE MATERIAL GRANULAR PARA DISTANCIAS >1KM |  | 176d | 2024-11-21 | 2025-05-15 | A1100 SS, A1290 SS, A1450 | 24d |  |  | TRANSPORTE DE MATERIAL GRANULAR PARA DISTANCIAS >1KM [1585.7 h]; Camión Volquete 15 m3 [7311.85 h] | 2,149,507.78 |
| A1060 |  | TRANSPORTE DE MATERIAL EXCEDENTE PARA DISTANCIAS <1KM |  | 176d | 2024-11-21 | 2025-05-15 | A1100 SS, A1290 SS, A1450 | 24d |  |  | TRANSPORTE DE MATERIAL EXCEDENTE PARA DISTANCIAS <1KM [134 h]; Camión Volquete 15 m3 [603 h] | 177,029.06 |
| A1070 |  | TRANSPORTE DE MATERIAL EXCEDENTE PARA DISTANCIAS >1KM |  | 176d | 2024-11-21 | 2025-05-15 | A1100 SS, A1290 SS, A1450 | 24d |  |  | TRANSPORTE DE MATERIAL EXCEDENTE PARA DISTANCIAS >1KM [1016.86 h]; Camión Volquete 15 m3 [4688.86 h] | 1,378,411.66 |
|  | 2 | **INTERVENCIÓN PAISAJISMO - HUMEDAL VILLA MARIA MARGEN DERECHO** |  |  | 2024-11-11 | 2025-06-08 |  |  |  |  |  |  |
|  | 1 | **OBRAS PRELIMINARES** |  |  | 2024-11-11 | 2025-05-21 |  |  |  |  |  |  |
| A1080 |  | MOVILIZACIÓN Y DEMOVILIZACIÓN DE EQUIPOS Y HERRAMIENTAS (ARQUITECTURA Y PAISAJISMO) |  | 17d | 2024-11-11 | 2024-11-27 | A1450 SS | 0d |  |  |  | 58,520 |
| A1100 |  | ELIMINACION DE RESIDUOS SOLIDOS GENERALES MUNICIPALES |  | 75d | 2024-11-21 | 2025-02-03 | A1080 SS+10d | 0d |  |  | SC ELIMINACION DE RESIDUOS SOLIDOS GENERALES MUNICIPALES [63383]; Cargador Sobre Llantas [888 h] | 2,568,894.75 |
| A1090 |  | TRAZO Y REPLANTEO PRELIMINAR |  | 175d | 2024-11-28 | 2025-05-21 | A1080 | 18d |  |  | Equipos [254 h]; Herramientas Manuales [156 h]; ACERO CORRUGADO fy = 4200 kg/cm2 GRADO 60 [4767]; YESO BOLSA 18 kg [1268]; PINTURA ESMALTE SINTETICO TEKNO [79]; CORDEL [12069]; MO - TRAZO Y REPLANTEO INICIAL [3120 h] | 154,472.09 |
|  | 2 | **MOVIMIENTO DE TIERRAS** |  |  | 2024-11-11 | 2025-05-06 |  |  |  |  |  |  |
| A1160 |  | ELIMINACION DE MATERIAL EXCEDENTE (DME´S) |  | 0d | 2024-11-11 | 2024-11-11 |  | 210d |  |  |  |  |
| A1110 |  | CORTE PARA CIMENTACIÓN DE DIQUE NATURALIZADO h=30cm |  | 17d | 2025-01-19 | 2025-02-04 | A1100 FF+1d | 0d |  |  | MO - CORTE PARA CIMENTACIÓN DE DIQUE NATURALIZADO h=30cm [331 h]; Herramientas Manuales [17 h]; Tractor Oruga [207 h] | 87,750.27 |
| A1120 |  | PERFILADO Y COMPACTACION EN ZONA DE CORTE |  | 14d | 2025-01-26 | 2025-02-08 | A1110 SS+7d | 0d |  |  | MO - PERFILADO Y COMPACTACION EN ZONA DE CORTE [344 h]; Herramientas Manuales [18 h]; Rodillo Liso Vibratorio [163 h]; Motoniveladora [163 h]; Camion Cisterna [85 h] | 119,474.51 |
| A1130 |  | CONFORMACIÓN DE CUERPO DE DIQUE NATURALZADO CON RELLENO COMPACTADO |  | 43d | 2025-02-09 | 2025-03-23 | A1120 | 0d |  |  | MO - CONFORMACIÓN DE CUERPO DE DIQUE NATURALZADO CON RELLENO COMPACTADO [3674 h]; Herramientas Manuales [111 h]; Camion Cisterna [602 h]; Rodillo Liso Vibratorio [452 h]; Motoniveladora [602 h]; Excavadora Oruga [90 h]; AFIRMADO [40005]; SC ZARANDEO DE MATERIAL PROPIO Y CARGUIO DE MATERIAL GRANULAR [32004] | 2,119,261.17 |
| A1140 |  | EXCAVACIÓN MANUAL PARA INSTALACIÓN DE BORDILLOS Y CIMENTACIONES |  | 44d | 2025-03-24 | 2025-05-06 | A1130 | 9d | 0d |  | MO - EXCAVACIÓN MANUAL PARA INSTALACIÓN DE BORDILLOS Y CIMENTACIONES [1371 h]; Herramientas Manuales [69 h] | 29,016.14 |
| A1150 |  | EXCAVACIÓN PARA MEJORAMIENTO DE SUELO CON TIERRA VEGETAL |  | 2d | 2025-03-24 | 2025-03-25 | A1140 SS | 75d |  |  | MO - EXCAVACIÓN PARA MEJORAMIENTO DE SUELO CON TIERRA VEGETAL [6 h]; Herramientas Manuales [1 h]; Excavadora Oruga [3 h] | 1,397.4 |

Notes:
- A1080: Expenses: SC MOVILIZACION Y DESMOVILIZACION DE MAQUINARIAS Y EQUIPOS PESADOS - DERECHO 58520

| ID | WBS | Activity | Duration | Start | Finish | Predecessors | Total float | Free float | Resources | Cost |
| --- | --- | --- | --- | --- | --- | --- | --- | --- | --- | --- |
|  | 3 | **PAVIMENTOS, RECUBRIMIENTOS Y BORDILLOS** |  | 2025-04-28 | 2025-06-07 |  |  |  |  |  |
| A1170 |  | PISO TIERRA APISONADA (h=0.35cm) | 37d | 2025-04-28 | 2025-06-03 | A1260 | 0d |  | MO - PISO TIERRA APISONADA (h=0.35cm) [5950 h]; Herramientas Manuales [298 h]; Rodillo Chupetero [2290 h]; AGUA [2146]; MANTA DE ASFALTO [22529] | 899,627.02 |
| A1180 |  | RECUBRIMIENTO DE PIEDRA DEL LUGAR e=0.05cm | 11d | 2025-05-16 | 2025-05-26 | A1170 SS+18d | 0d |  | MO - RECUBRIMIENTO DE PIEDRA DEL LUGAR e=0.05cm [268 h]; Equipos [1 h]; Herramientas Manuales [14 h]; SELECCIÓN Y ACOPIO DE PIEDRA [94]; MORTERO [31] | 9,102.96 |
| A1190 |  | BORDILLOS DE PIEDRA DEL LUGAR | 23d | 2025-05-16 | 2025-06-07 | A1180 SS, A1140 | 0d |  | MO - BORDILLOS DE PIEDRA DEL LUGAR [7665 h]; Herramientas Manuales [384 h]; SELECCIÓN Y ACOPIO DE PIEDRA [7478]; MORTERO [2244] | 309,589.2 |
|  | 4 | **MOBILIARIOS, BARANDAS Y ESCALERAS** |  | 2025-05-12 | 2025-06-08 |  |  |  |  |  |
| A1240 |  | BOLARDOS DE PIEDRA | 28d | 2025-05-12 | 2025-06-08 | A1190 FF+1d, A1260 | 0d |  | MO - BOLARDOS DE PIEDRA [368 h]; SELECCION Y ACOPIO DE PIEDRA [153]; SC TRASLADO DE BOLARDOS A ZONA DE ACOPIO [153] | 12,830.58 |
| A1200 |  | TACHOS DE BASURA, INCLUYE CIMENTACIÓN | 23d | 2025-05-16 | 2025-06-07 | A1180 SS, A1380 | 1d | 0d | SC EXCAVACION DE CIMENTACION MANUAL [4]; SC ELIMINACION DE MATERIAL EXCEDENTE [2]; SC CONCRETO PARA CIMENTACION MEZCLA 1:10 + 30% PG [3]; SC ENCOFRADO Y DESENCOFRADO [48]; SC SUMINISTRO E INSTALACION DE TACHOS DE MADERA [19]; SC ACERO ESTRUCTURAL fy=4200 kg/cm2 [213]; SC COLOCACION DE CONCRETO 175 KG/CM2 [1] | 13,347.31 |
| A1210 |  | BANCAS DE CONCRETO, INCLUYE CIMENTACIÓN | 19d | 2025-05-16 | 2025-06-03 | A1200 SS, A1390 | 1d | 0d | SC EXCAVACION DE CIMENTACION MANUAL [12]; SC ELIMINACION DE MATERIAL EXCEDENTE [12]; SC CONCRETO PARA CIMENTACION MEZCLA 1:10 + 30% PG [8]; SC COLOCACION DE CONCRETO 175 KG/CM2 [7]; SC ACERO ESTRUCTURAL fy=4200 kg/cm2 [620]; SC ENCOFRADO Y DESENCOFRADO [125] | 21,019.32 |
| A1220 |  | POSTES DE ILUMINACION, INCLUYE LUMINARIA Y CIMENTACION | 23d | 2025-05-16 | 2025-06-07 | A1210 SS, A1400 | 1d | 0d | MO - POSTES DE ILUMINACION, INCLUYE LUMINARIA Y CIMENTACION [59 h]; Herramientas Manuales [3 h]; CLAVOS PARA MADERA CON CABEZA 1 1/2" [4]; POSTE DE EUCALIPTO D=6"X4M [19]; SC EXCAVACION DE CIMENTACION MANUAL [1]; SC CONCRETO PARA CIMENTACION MEZCLA 1:10 + 30% PG [8]; SC ACERO ESTRUCTURAL fy=4200 kg/cm2 [133]; SC COLOCACION DE BREA LIQUIDA [19]; SC SUMINISTRO E INSTALACION DE LUMINARIA SOLAR [19]; SC ENCOFRADO Y DESENCOFRADO [9]; SC SUMINISTRO E INSTALACION DE PANEL INFORMATIVO [19]; SC ACABADO DE PINTURA BARNIZ POLIURETANO (2 MANOS) [19] | 67,632.4 |
| A1230 |  | SEÑALETICA INFORMATIVA | 11d | 2025-05-16 | 2025-05-26 | A1220 SS, A1410 | 5d | 0d | MO - SEÑALETICA INFORMATIVA [48 h]; Equipos [24 h]; Herramientas Manuales [3 h]; ABRAZADERA DE 1" [50]; PINTURA ANTICORROSIVA [1]; DISOLVENTE XILOL [1]; SOLDADURA AWS E6011 [2]; LAMINA REFLECTIVA ALTA INTENSIDAD [3]; PLATINAS DE ACERO INOXIDABLE E=1/8" [25] | 4,668.25 |
| A1250 |  | TRANQUERA | 19d | 2025-05-16 | 2025-06-03 | A1230 SS, A1430 | 5d |  | MO - TRANQUERA [12 h]; CLAVOS PARA MADERA CON CABEZA 1 1/2" [6]; LISTON DE EUCALIPTO D=2"X4M [6]; LISTON DE EUCALIPTO D=3"X4M [6]; LISTON DE EUCALIPTO D=4"X4M [6]; BISAGRAS DE FIERRO [6]; SC ACERO ESTRUCTURAL fy=4200 kg/cm2 [42]; SC COLOCACION DE BREA LIQUIDA [6]; SC CONCRETO CICLOPEO 175 KG/CM2 + 30% PG [6]; SC ACABADO DE PINTURA BARNIZ POLIURETANO (2 MANOS) [6] | 4,678.86 |
|  | 5 | **OBRAS PRELIMINARES PAISAJISMO** |  | 2025-03-24 | 2025-04-27 |  |  |  |  |  |
| A1260 |  | MEJORAMIENTO DE SUELO CON TIERRA DE CHACRA (incluye despedregado y rastrillado) | 35d | 2025-03-24 | 2025-04-27 | A1130 | 0d |  | MO - MEJORAMIENTO DE SUELO CON TIERRA DE CHACRA (incluye despedregado y rastrillado) [6653 h]; Herramientas Manuales [333 h]; TIERRA DE CHACRA [22163]; SC TRANSPORTE DE TIERRA DE CHACRA [19272] | 1,715,766.57 |
|  | 3 | **INTERVENCIÓN PAISAJISMO - HUMEDAL VILLA MARIA MARGEN IZQUIERDO** |  | 2024-11-11 | 2025-05-16 |  |  |  |  |  |
|  | 1 | **OBRAS PRELIMINARES** |  | 2024-11-11 | 2025-05-16 |  |  |  |  |  |
| A1270 |  | MOVILIZACIÓN Y DEMOVILIZACIÓN DE EQUIPOS Y HERRAMIENTAS (ARQUITECTURA Y PAISAJISMO) | 17d | 2024-11-11 | 2024-11-27 | A1450 SS | 23d | 0d |  | 58,520 |
| A1290 |  | ELIMINACION DE RESIDUOS SOLIDOS GENERALES MUNICIPALES | 56d | 2024-11-21 | 2025-01-15 | A1100 SS | 24d | 0d | Cargador Sobre Llantas [682 h]; SC ELIMINACION DE RESIDUOS SOLIDOS GENERALES MUNICIPALES [48706] | 1,974,049.32 |
| A1280 |  | TRAZO Y REPLANTEO PRELIMINAR | 170d | 2024-11-28 | 2025-05-16 | A1270 | 23d |  | Equipos [204 h]; Herramientas Manuales [126 h]; ACERO CORRUGADO fy = 4200 kg/cm2 GRADO 60 [3826]; YESO BOLSA 18 kg [1017]; PINTURA ESMALTE SINTETICO TEKNO [63]; CORDEL [9686]; MO - TRAZO Y REPLANTEO INICIAL [2504 h] | 123,974.94 |
|  | 2 | **MOVIMIENTO DE TIERRAS** |  | 2024-11-11 | 2025-03-03 |  |  |  |  |  |
| A1340 |  | ELIMINACION DE MATERIAL EXCEDENTE (DME´S) | 0d | 2024-11-11 | 2024-11-11 |  | 210d |  |  |  |
| A1300 |  | CORTE PARA CIMENTACIÓN DE DIQUE NATURALIZADO h=30cm | 35d | 2025-01-02 | 2025-02-05 | A1100 FF+2d | 123d |  | MO - CORTE PARA CIMENTACIÓN DE DIQUE NATURALIZADO h=30cm [706 h]; Herramientas Manuales [36 h]; Tractor Oruga [442 h] | 187,339.23 |
| A1310 |  | PERFILADO Y COMPACTACION EN ZONA DE CORTE | 14d | 2025-02-01 | 2025-02-14 | A1120 SS+6d, A1290 | 23d | 0d | MO - PERFILADO Y COMPACTACION EN ZONA DE CORTE [277 h]; Herramientas Manuales [14 h]; Rodillo Liso Vibratorio [131 h]; Motoniveladora [131 h]; Camion Cisterna [68 h] | 95,886.86 |
| A1320 |  | CONFORMACIÓN DE CUERPO DE DIQUE NATURALZADO CON RELLENO COMPACTADO | 5d | 2025-02-15 | 2025-02-19 | A1310 | 23d | 0d | MO - CONFORMACIÓN DE CUERPO DE DIQUE NATURALZADO CON RELLENO COMPACTADO [505 h]; Herramientas Manuales [16 h]; Rodillo Liso Vibratorio [62 h]; Excavadora Oruga [13 h]; Motoniveladora [83 h]; Camion Cisterna [83 h]; AFIRMADO [5491]; SC ZARANDEO DE MATERIAL PROPIO Y CARGUIO DE MATERIAL GRANULAR [4393] | 290,852.81 |
| A1330 |  | EXCAVACIÓN MANUAL PARA INSTALACIÓN DE BORDILLOS Y CIMENTACIONES | 12d | 2025-02-20 | 2025-03-03 | A1320 | 77d | 22d | MO - EXCAVACIÓN MANUAL PARA INSTALACIÓN DE BORDILLOS Y CIMENTACIONES [308 h]; Herramientas Manuales [16 h] | 6,503.22 |

Notes:
- A1270: Expenses: SC MOVILIZACION Y DESMOVILIZACION DE MAQUINARIAS Y EQUIPOS PESADOS - IZQUIERDO 58520

| ID | WBS | Activity | Duration | Start | Finish | Predecessors | Total float | Free float | Resources | Cost |
| --- | --- | --- | --- | --- | --- | --- | --- | --- | --- | --- |
|  | 3 | **PAVIMENTOS, RECUBRIMIENTOS Y BORDILLOS** |  | 2025-03-14 | 2025-04-14 |  |  |  |  |  |
| A1350 |  | PISO TIERRA APISONADA (h=0.35cm) | 12d | 2025-03-14 | 2025-03-25 | A1440 | 55d | 0d | MO - PISO TIERRA APISONADA (h=0.35cm) [2203 h]; Herramientas Manuales [111 h]; Rodillo Chupetero [848 h]; AGUA [795]; MANTA DE ASFALTO [8341] | 333,072.21 |
| A1360 |  | RECUBRIMIENTO DE PIEDRA DEL LUGAR e=0.05cm | 7d | 2025-03-26 | 2025-04-01 | A1350 | 68d |  | MO - RECUBRIMIENTO DE PIEDRA DEL LUGAR e=0.05cm [137 h]; Equipos [1 h]; Herramientas Manuales [7 h]; SELECCIÓN Y ACOPIO DE PIEDRA [49]; MORTERO [16] | 4,663.81 |
| A1370 |  | BORDILLOS DE PIEDRA DEL LUGAR | 20d | 2025-03-26 | 2025-04-14 | A1350, A1330 | 55d |  | MO - BORDILLOS DE PIEDRA DEL LUGAR [1718 h]; Herramientas Manuales [86 h]; SELECCIÓN Y ACOPIO DE PIEDRA [1676]; MORTERO [503] | 69,386.4 |
|  | 4 | **MOBILIARIOS, BARANDAS Y ESCALERAS** |  | 2025-03-14 | 2025-05-16 |  |  |  |  |  |
| A1380 |  | TACHOS DE BASURA, INCLUYE CIMENTACIÓN | 25d | 2025-03-14 | 2025-04-07 | A1440 | 39d | 38d | SC EXCAVACION DE CIMENTACION MANUAL [1]; SC ELIMINACION DE MATERIAL EXCEDENTE [1]; SC CONCRETO PARA CIMENTACION MEZCLA 1:10 + 30% PG [1]; SC COLOCACION DE CONCRETO 175 KG/CM2 [1]; SC ACERO ESTRUCTURAL fy=4200 kg/cm2 [45]; SC SUMINISTRO E INSTALACION DE TACHOS DE MADERA [4]; SC ENCOFRADO Y DESENCOFRADO [10] | 2,809.96 |
| A1390 |  | BANCAS DE CONCRETO, INCLUYE CIMENTACIÓN | 15d | 2025-03-14 | 2025-03-28 | A1440 | 49d | 48d | SC EXCAVACION DE CIMENTACION MANUAL [9]; SC ELIMINACION DE MATERIAL EXCEDENTE [9]; SC CONCRETO PARA CIMENTACION MEZCLA 1:10 + 30% PG [6]; SC COLOCACION DE CONCRETO 175 KG/CM2 [5]; SC ACERO ESTRUCTURAL fy=4200 kg/cm2 [457]; SC ENCOFRADO Y DESENCOFRADO [92] | 15,487.92 |
| A1400 |  | POSTES DE ILUMINACION, INCLUYE LUMINARIA Y CIMENTACION | 25d | 2025-03-14 | 2025-04-07 | A1440 | 39d | 38d | MO - POSTES DE ILUMINACION, INCLUYE LUMINARIA Y CIMENTACION [16 h]; Herramientas Manuales [1 h]; CLAVOS PARA MADERA CON CABEZA 1 1/2" [1]; POSTE DE EUCALIPTO D=6"X4M [5]; SC EXCAVACION DE CIMENTACION MANUAL [1]; SC CONCRETO PARA CIMENTACION MEZCLA 1:10 + 30% PG [2]; SC ACERO ESTRUCTURAL fy=4200 kg/cm2 [35]; SC COLOCACION DE BREA LIQUIDA [5]; SC SUMINISTRO E INSTALACION DE LUMINARIA SOLAR [5]; SC ENCOFRADO Y DESENCOFRADO [3]; SC SUMINISTRO E INSTALACION DE PANEL INFORMATIVO [5]; SC ACABADO DE PINTURA BARNIZ POLIURETANO (2 MANOS) [5] | 17,798 |
| A1410 |  | SEÑALETICA INFORMATIVA | 10d | 2025-03-14 | 2025-03-23 | A1440 | 58d | 53d | MO - SEÑALETICA INFORMATIVA [12 h]; Equipos [6 h]; Herramientas Manuales [1 h]; ABRAZADERA DE 1" [12]; PINTURA ANTICORROSIVA [1]; DISOLVENTE XILOL [1]; SOLDADURA AWS E6011 [1]; LAMINA REFLECTIVA ALTA INTENSIDAD [1]; PLATINAS DE ACERO INOXIDABLE E=1/8" [6] | 1,120.38 |
| A1420 |  | BOLARDOS DE PIEDRA | 64d | 2025-03-14 | 2025-05-16 | A1440 | 23d |  | MO - BOLARDOS DE PIEDRA [1853 h]; SELECCION Y ACOPIO DE PIEDRA [772]; SC TRASLADO DE BOLARDOS A ZONA DE ACOPIO [772] | 64,739.92 |
| A1430 |  | TRANQUERA | 15d | 2025-03-14 | 2025-03-28 | A1440 | 53d | 48d | MO - TRANQUERA [2 h]; CLAVOS PARA MADERA CON CABEZA 1 1/2" [1]; LISTON DE EUCALIPTO D=2"X4M [1]; LISTON DE EUCALIPTO D=3"X4M [1]; LISTON DE EUCALIPTO D=4"X4M [1]; BISAGRAS DE FIERRO [1]; SC ACERO ESTRUCTURAL fy=4200 kg/cm2 [7]; SC COLOCACION DE BREA LIQUIDA [1]; SC CONCRETO CICLOPEO 175 KG/CM2 + 30% PG [1]; SC ACABADO DE PINTURA BARNIZ POLIURETANO (2 MANOS) [1] | 779.81 |
|  | 5 | **OBRAS PRELIMINARES PAISAJISMO** |  | 2025-02-20 | 2025-03-13 |  |  |  |  |  |
| A1440 |  | MEJORAMIENTO DE SUELO CON TIERRA DE CHACRA (incluye despedregado y rastrillado) | 22d | 2025-02-20 | 2025-03-13 | A1320 | 23d | 0d | MO - MEJORAMIENTO DE SUELO CON TIERRA DE CHACRA (incluye despedregado y rastrillado) [6044 h]; Herramientas Manuales [303 h]; TIERRA DE CHACRA [20135]; SC TRANSPORTE DE TIERRA DE CHACRA [17509] | 1,558,755.05 |
